# RIS_Move

Schedule from MS Project, 2004-03-22 to 2004-12-29, A marks actual dates.
RIPE NCC

## Calendars

- Standard: Mon-Fri 08:00-12:00, 13:00-17:00; Sat-Sun off. Exceptions (off unless hours are given): 2004-04-09, 2004-04-12, 2004-04-26 to 2004-04-30, 2004-05-03 to 2004-05-07, 2004-05-20, 2004-05-31.

## Resources

| Resource |
| --- |
| Alexis |
| James |
| Matthew |
| Ruud |
| Shane |
| Henk |
| Arife |
| TRA |
| FO |
| Engin |
| Gerard |
| Bruce |
| Katie |
| OPS |
| Vasco |

## Schedule

| ID | WBS | Task | Duration | Start | Finish | Predecessors | Complete | Remaining | Baseline start | Baseline finish | Baseline duration | Total slack | Constraint | Resources | Work | Actual work |
| --- | --- | --- | --- | --- | --- | --- | --- | --- | --- | --- | --- | --- | --- | --- | --- | --- |
| 1 | 1 | **Procedures** | 188.5d | 2004-03-22 A | 2004-12-29 |  | 23% | 144.65d | 2004-03-22 | 2004-12-29 | 188.5d | 0d |  |  | 326h | 225.02h |
| 2 | 1.1 | Planning issues | 1w | 2004-03-22 A | 2004-03-26 A |  | 100% |  | 2004-03-22 | 2004-03-26 | 1w |  |  | Ruud; Shane; Henk | 120h | 120h |
| 3 | 1.2 | 1st draft of procedures document | 2.4w | 2004-03-29 A | 2004-04-16 A | 2 | 100% |  | 2004-03-29 | 2004-04-16 | 2.4w |  |  | Arife [25%]; James [25%]; Gerard [25%]; Engin [25%] | 80h | 80h |
| 4 | 1.3 | Approve draft | 1d | 2004-04-16 A | 2004-04-19 A | 3 | 100% |  | 2004-04-16 | 2004-04-19 | 1d |  |  | Ruud; Shane; Henk | 24h | 24h |
| 5 | 1.4 | Maintain/expand draft | 3.04mo | 2004-10-05 A | 2004-12-29 | 4 | 1% | 3.02mo | 2004-10-05 | 2004-12-29 | 3.04mo | 0d |  | Arife [10%]; Gerard [10%]; Engin [10%]; James [10%] | 102h | 1.02h |
| 7 | 2 | **RIS Training** | 16.5d | 2004-03-22 A | 2004-04-15 A |  | 100% |  | 2004-03-22 | 2004-04-15 | 16.5d |  |  |  | 96h | 96h |
| 8 | 2.1 | Prepare | 2d | 2004-03-22 A | 2004-04-06 A |  | 100% |  | 2004-03-22 | 2004-04-06 | 2d |  |  | Arife [75%]; James [50%]; Henk [50%]; Matthew [50%] | 32h | 32h |
| 9 | 2.2 | Present | 4h | 2004-04-07 A | 2004-04-07 A | 8 | 100% |  | 2004-04-07 | 2004-04-07 | 4h |  | must start on 2004-04-07 | Arife; James; Gerard; Bruce; Engin; Katie; Matthew; Henk | 32h | 32h |
| 10 | 2.3 | Self Study by team members | 4d | 2004-04-07 A | 2004-04-15 A | 9 | 100% |  | 2004-04-07 | 2004-04-15 | 4d |  |  | Gerard; Bruce; Katie; Engin [25%] | 32h | 32h |
| 12 | 3 | RIPE48 | 0.12d | 2004-04-23 A | 2004-05-07 A |  | 100% |  | 2004-05-07 | 2004-05-07 | 0d |  | must finish on 2004-05-07 | Henk | 1h | 1h |
| 13 | 4 | Routing Training | 51.06d | 2004-05-25 | 2004-08-05 | 12 |  |  | 2004-05-25 | 2004-08-05 | 51.06d | 104.44d | finish no earlier than 2004-06-11 | Gerard; Bruce; Katie; Engin | 84h |  |
| 15 | 5 | **RRC's to Linux** | 67.5d | 2004-03-22 A | 2004-07-13 A |  | 100% |  | 2004-03-22 | 2004-06-18 | 50.5d |  |  |  | 393.11h | 393.11h |
| 16 | 5.1 | **Preparations** | 41d | 2004-03-22 A | 2004-06-04 A |  | 100% |  |  |  |  |  |  |  | 252h | 252h |
| 17 | 5.1.1 | Check H/W support | 8h | 2004-04-19 A | 2004-04-19 A |  | 100% |  | 2004-04-19 | 2004-04-19 | 8h |  | start no earlier than 2004-04-19 | Arife [50%] | 4h | 4h |
| 18 | 5.1.2 | Check S/W Support | 8h | 2004-03-22 A | 2004-03-25 A |  | 100% |  | 2004-03-22 | 2004-03-25 | 8h |  |  | James [50%] | 4h | 4h |
| 19 | 5.1.3 | Build RRC out of spare 2650 | 1w | 2004-05-10 A | 2004-05-14 A | 17, 18, 12 | 100% |  | 2004-05-10 | 2004-05-14 | 1w |  |  | Arife [50%]; James [50%]; Bruce; Gerard [50%] | 80h | 80h |
| 20 | 5.1.4 | Test RRC | 1w | 2004-05-17 A | 2004-05-24 A | 19 | 100% |  | 2004-05-17 | 2004-05-24 | 1w |  |  | Arife [50%]; James [50%]; Bruce; Gerard | 80h | 80h |
| 21 | 5.1.5 | Write instructions for upgrade | 3d | 2004-05-25 A | 2004-06-02 A | 20 | 100% |  | 2004-05-25 | 2004-06-02 | 3d |  |  | Arife | 20h | 20h |
| 22 | 5.1.6 | Burn CD's | 1d | 2004-05-25 A | 2004-05-25 A | 20 | 100% |  | 2004-05-25 | 2004-05-25 | 1d |  |  | OPS | 8h | 8h |
| 23 | 5.1.7 | Ship CD's | 3d | 2004-05-26 A | 2004-05-28 A | 22 | 100% |  | 2004-05-26 | 2004-05-28 | 3d |  |  | OPS; FO | 48h | 48h |
| 24 | 5.1.8 | Schedule Upgrades | 2d | 2004-05-28 A | 2004-06-04 A | 22 | 100% |  | 2004-05-28 | 2004-06-04 | 2d |  | finish no earlier than 2004-06-04 | Arife [50%] | 8h | 8h |
| 25 | 5.2 | **Upgrade machines** | 30.5d | 2004-05-31 A | 2004-07-13 A |  | 100% |  | 2004-05-31 | 2004-06-18 | 13.5d |  |  |  | 96h | 96h |
| 26 | 5.2.1 | rrc00/RIPENCC | 1d | 2004-06-01 A | 2004-06-03 A | 23 | 100% |  | 2004-06-01 | 2004-06-03 | 1d |  |  | Arife | 8h | 8h |
| 27 | 5.2.2 | rrc01/LINX | 1d | 2004-05-31 A | 2004-06-22 A | 23 | 100% |  | 2004-05-31 | 2004-06-02 | 1d |  | finish no later than 2004-06-22 | Bruce | 8h | 8h |
| 28 | 5.2.3 | rrc02/SFINX | 0.5d | 2004-05-31 A | 2004-06-25 A | 23 | 100% |  | 2004-06-01 | 2004-06-02 | 2d |  | finish no later than 2004-06-25 | Bruce [200%] | 8h | 8h |
| 29 | 5.2.4 | rrc03/AMSIX | 1d | 2004-06-01 A | 2004-06-01 A | 23 | 100% |  | 2004-06-01 | 2004-06-01 | 1d |  |  | James | 8h | 8h |
| 30 | 5.2.5 | rrc04/CIXP | 1d | 2004-06-02 A | 2004-06-29 A | 23 | 100% |  | 2004-06-02 | 2004-06-04 | 1d |  | finish no earlier than 2004-06-29 | Bruce | 8h | 8h |
| 31 | 5.2.6 | rrc05/VIX | 2d | 2004-06-01 A | 2004-06-24 A | 23 | 100% |  | 2004-06-01 | 2004-06-04 | 2d |  |  | Gerard [50%] | 8h | 8h |
| 32 | 5.2.7 | rrc06/DIXIE | 2d | 2004-06-01 A | 2004-06-25 A | 23 | 100% |  | 2004-05-31 | 2004-06-09 | 1d |  | finish no later than 2004-07-01 | James [50%] | 8h | 8h |
| 33 | 5.2.8 | rrc07/MAE | 2d | 2004-06-01 A | 2004-06-23 A | 23 | 100% |  | 2004-06-01 | 2004-06-08 | 2d |  |  | Gerard [50%] | 8h | 8h |
| 34 | 5.2.9 | rrc08/NETNOD | 1d | 2004-06-22 A | 2004-06-22 A | 23 | 100% |  | 2004-06-10 | 2004-06-11 | 1d |  | start no earlier than 2004-06-22 | Arife | 8h | 8h |
| 35 | 5.2.10 | rrc09/TIX | 2d | 2004-06-01 A | 2004-06-11 A | 23 | 100% |  | 2004-06-01 | 2004-06-11 | 2d |  |  | Gerard [50%] | 8h | 8h |
| 36 | 5.2.11 | rrc10/MIX | 2d | 2004-06-14 A | 2004-07-13 A | 23 | 100% |  | 2004-06-15 | 2004-06-16 | 1d |  | finish no earlier than 2004-07-13 | Bruce [50%] | 8h | 8h |
| 37 | 5.2.12 | rrc11/NYIIX | 2d | 2004-06-01 A | 2004-06-29 A | 23 | 100% |  | 2004-06-01 | 2004-06-15 | 2d |  |  | Gerard [50%] | 8h | 8h |
| 38 | 5.3 | rrc12/DENIX | 1.5d | 2004-06-18 A | 2004-07-02 A | 23 | 100% |  | 2004-06-17 | 2004-06-18 | 1d |  | must start on 2004-07-02 | James | 8h | 8h |
| 39 | 5.4 | Cleanup of daily tickets | 6d | 2004-06-07 A | 2004-06-17 A | 24 | 100% |  | 2004-06-07 | 2004-06-17 | 6.5d |  |  | Arife; Bruce; Gerard | 37.11h | 37.11h |

| ID | WBS | Task | Duration | Start | Finish | Predecessors | Complete | Remaining | Baseline start | Baseline finish | Baseline duration | Total slack | Free slack | Constraint | Resources | Work | Actual work |
| --- | --- | --- | --- | --- | --- | --- | --- | --- | --- | --- | --- | --- | --- | --- | --- | --- | --- |
| 41 | 6 | **Ongoing work** | 84d | 2004-03-22 A | 2004-08-04 |  | 66% | 28.29d | 2004-03-22 | 2004-08-04 | 84d | 104.5d |  |  |  | 692h | 418h |
| 42 | 6.1 | **MyASn development** | 79d | 2004-03-22 A | 2004-07-28 |  | 88% | 9.67d | 2004-03-22 | 2004-07-28 | 79d | 109.5d |  |  |  | 524h | 380h |
| 43 | 6.1.1 | WP3 | 18d | 2004-03-22 A | 2004-05-03 A |  | 100% |  | 2004-03-22 | 2004-05-03 | 18d |  |  | must start on 2004-03-22 | Alexis | 144h | 144h |
| 44 | 6.1.2 | Check WP3 | 3d | 2004-05-13 A | 2004-05-19 A | 43 | 100% |  | 2004-05-13 | 2004-05-19 | 3d |  |  | start no earlier than 2004-05-13 | James [50%]; Matthew | 28h | 28h |
| 45 | 6.1.3 | WP4 | 18d | 2004-05-24 A | 2004-07-05 A | 44 | 100% |  | 2004-05-24 | 2004-07-05 | 18d |  |  |  | Alexis | 144h | 144h |
| 46 | 6.1.4 | Check WP4 | 4d | 2004-07-06 A | 2004-07-14 A | 45 | 100% |  | 2004-07-06 | 2004-07-14 | 4d |  |  |  | James [50%]; Matthew [50%]; Katie [50%]; Engin [50%] | 64h | 64h |
| 47 | 6.1.5 | Handover | 6d | 2004-07-15 | 2004-07-28 | 46 |  |  | 2004-07-15 | 2004-07-28 | 6d | 109.5d |  |  | Katie; Engin; Alexis | 144h |  |
| 48 | 6.2 | Documentation/user training | 3w | 2004-07-15 A | 2004-08-04 | 46 | 25% | 2.25w | 2004-07-15 | 2004-08-04 | 3w | 104.5d |  |  | Matthew | 120h | 30h |
| 49 | 6.3 | RRC Installation UAE | 1.4w | 2004-03-29 | 2004-04-06 |  |  |  | 2004-03-29 | 2004-04-06 | 1.4w | 176.5d |  |  | Henk | 40h |  |
| 50 | 6.4 | RRC upgrade Stockholm | 1d | 2004-04-15 A | 2004-04-15 A |  | 100% |  | 2004-04-16 | 2004-05-26 | 1d |  |  | must start on 2004-04-15 | Arife | 8h | 8h |
| 52 | 7 | **Integration with OPS** | 119.5d | 2004-06-14 A | 2004-11-26 |  | 97% | 3.78d | 2004-06-18 | 2004-11-26 | 115d | 0d |  |  |  | 161h | 157h |
| 53 | 7.1 | Define RRC class in kroot system | 3.5d | 2004-07-14 A | 2004-11-26 A |  | 100% |  | 2004-07-14 | 2004-11-26 | 3.5d |  |  | start no earlier than 2004-06-14 | Bruce | 24h | 24h |
| 54 | 7.2 | Move HW support to ops | 0.99d | 2004-06-14 A | 2004-06-18 A |  | 100% |  | 2004-06-23 | 2004-06-30 | 1d |  |  | start no earlier than 2004-06-14 | Gerard | 7.89h | 7.89h |
| 55 | 7.3 | Integrate monitoring system | 13.97d | 2004-06-18 A | 2004-07-16 A |  | 100% |  | 2004-06-18 | 2004-07-09 | 11.61d |  |  | start no earlier than 2004-06-14 | Arife [230%]; Bruce; Gerard | 97h | 97h |
| 56 | 7.4 | Migrate logging to kroot model | 3.51d | 2004-06-14 A | 2004-11-11 A |  | 100% |  | 2004-06-23 | 2004-11-23 | 2.5d |  |  | start no earlier than 2004-06-14 | Bruce; Gerard | 16.11h | 16.11h |
| 57 | 7.5 | Software sync | 20.89h | 2004-06-14 A | 2004-06-17 |  | 70% | 6.22h | 2004-06-18 | 2004-06-23 | 24.89h | 4.53d | 0d | start no earlier than 2004-06-14 | Bruce; Gerard [225.1%] | 16h | 12h |
| 59 | 8 | **Integration with SED** | 109.5d | 2004-06-18 A | 2004-11-18 | 15 | 6% | 103.16d | 2004-06-18 | 2004-11-19 | 110d | 29d |  |  |  | 262h | 48h |
| 60 | 8.1 | Change iii page | 13.62d | 2004-06-18 | 2004-07-21 |  |  |  | 2004-06-18 | 2004-07-22 | 13.62d | 115d |  | start no earlier than 2004-06-18 | James [225.1%]; Arife [59.8%]; Bruce [50%]; Engin [25%] | 54h |  |
| 61 | 8.2 | Start sending tickets to SED | 6d | 2004-06-18 A | 2004-10-04 A |  | 100% |  | 2004-06-23 | 2004-10-07 | 6d |  |  | start no earlier than 2004-06-18 | Arife; Engin; Katie | 48h | 48h |
| 62 | 8.3 | Maintain docs on iii | 16.8w | 2004-06-18 | 2004-11-18 |  |  |  | 2004-06-18 | 2004-11-19 | 16.9w | 29d |  | start no earlier than 2004-06-18 | James [50%]; Arife [10%]; Bruce [20%]; Engin [10%] | 160h |  |
| 64 | 9 | **SW development training** | 4.5d | 2004-05-10 A | 2004-05-14 A |  | 100% |  | 2004-05-10 | 2004-05-14 | 4.5d |  |  |  |  | 44h | 44h |
| 65 | 9.1 | Prepare | 3d | 2004-05-10 A | 2004-05-12 A |  | 100% |  | 2004-05-10 | 2004-05-12 | 3d |  |  | must start on 2004-05-10 | Shane | 24h | 24h |
| 66 | 9.2 | Present | 4h | 2004-05-14 A | 2004-05-14 A | 65 | 100% |  | 2004-05-14 | 2004-05-14 | 4h |  |  | must start on 2004-05-14 | Arife; James; Shane; Bruce; Gerard | 20h | 20h |
| 68 | 10 | **Software move** | 113.36d | 2004-06-17 | 2004-11-23 |  |  |  | 2004-06-23 | 2004-11-29 | 113.36d | 4.53d | 0d |  |  | 407.11h |  |
| 69 | 10.1 | Document existing software | 4.18w | 2004-06-17 | 2004-09-07 | 64, 57 |  |  | 2004-06-23 | 2004-09-13 | 4.18w | 4.53d | 0d | finish no earlier than 2004-06-18 | Arife; James | 127.11h |  |
| 70 | 10.2 | Review documentation | 1.56w | 2004-06-17 | 2004-08-31 | 69SS, 64 |  |  | 2004-06-23 | 2004-09-07 | 1.2w | 64.1d |  |  | Engin [110.8%]; Katie | 80h |  |
| 71 | 10.3 | PRtraceroute with RISwhois | 1w | 2004-09-07 | 2004-09-14 | 69 |  |  | 2004-09-13 | 2004-09-20 | 1w | 54.51d |  |  | Katie | 40h |  |
| 72 | 10.4 | Maintain docs on iii | 11w | 2004-09-07 | 2004-11-23 | 69 |  |  | 2004-09-13 | 2004-11-29 | 11w | 4.53d |  |  | Arife [10%]; Engin [10%]; James [10%]; Katie [10%] | 160h |  |

| ID | WBS | Task | Duration | Start | Finish | Predecessors | Complete | Remaining | Baseline start | Baseline finish | Baseline duration | Total slack | Constraint | Resources | Work | Actual work |
| --- | --- | --- | --- | --- | --- | --- | --- | --- | --- | --- | --- | --- | --- | --- | --- | --- |
| 74 | 11 | **Helpdesk handover** | 44d | 2004-05-10 A | 2004-07-12 A | 12 | 100% |  | 2004-05-10 | 2004-06-22 | 30d |  |  |  | 232h | 232h |
| 75 | 11.1 | Train SED to handle peering requests | 4d | 2004-05-10 A | 2004-05-17 A |  | 100% |  | 2004-05-10 | 2004-05-17 | 4d |  |  | Matthew [50%]; Engin [50%]; Katie [50%] | 24h | 24h |
| 76 | 11.2 | Peering requests to SED | 1d | 2004-05-18 A | 2004-05-18 A | 75 | 100% |  | 2004-05-18 | 2004-05-18 | 1d |  |  | Engin; Katie | 16h | 16h |
| 77 | 11.3 | Train SED to handle tickets | 2w | 2004-06-01 A | 2004-07-06 A |  | 100% |  | 2004-05-10 | 2004-06-16 | 1w |  | start no earlier than 2004-06-01 | Arife; Engin; Katie; Vasco | 160h | 160h |
| 78 | 11.4 | All tickets to Helpdesk | 4d | 2004-07-07 A | 2004-07-12 A | 77 | 100% |  | 2004-06-17 | 2004-06-22 | 4d |  | start no earlier than 2004-06-17 | Engin [50%]; Katie [50%] | 32h | 32h |
| 80 | 12 | **Research issues** | 183.97d | 2004-03-22 A | 2004-12-22 |  | 12% | 161.18d | 2004-03-22 | 2004-12-29 | 188.47d | 4.53d |  |  | 508h | 40h |
| 81 | 12.1 | Analysis of Beacon Data | 3.7w | 2004-11-23 | 2004-12-17 | 68 |  |  | 2004-11-29 | 2004-12-24 | 3.7w | 7.53d |  | Arife; Henk | 240h |  |
| 82 | 12.2 | BGP Stability Index | 4w | 2004-11-23 | 2004-12-22 | 68 |  |  | 2004-11-29 | 2004-12-29 | 4w | 4.53d |  | James | 160h |  |
| 83 | 12.3 | Reshuffle Website | 2.2w | 2004-03-22 | 2004-06-04 |  |  |  | 2004-03-22 | 2004-06-04 | 2.2w | 147.5d |  | Matthew | 68h |  |
| 84 | 12.4 | IDRWS report | 1.4w | 2004-03-24 A | 2004-04-22 A |  | 100% |  | 2004-03-24 | 2004-04-22 | 1.4w |  |  | Matthew | 40h | 40h |
| 86 | 13 | **Regular tasks** | 187.5d | 2004-03-23 A | 2004-12-29 |  | 51% | 92.35d | 2004-03-23 | 2004-12-29 | 187.5d | 0d |  |  | 696h | 300h |
| 87 | 13.1 | **Regular Maintenance** | 187.5d | 2004-03-23 A | 2004-12-29 |  | 49% | 95.83d | 2004-03-23 | 2004-12-29 | 187.5d | 0d |  |  | 480h | 204h |
| 88 | 13.1.1 | Regular Maintenance 1 | 12h | 2004-03-23 A | 2004-03-24 A |  | 100% |  | 2004-03-23 | 2004-03-24 | 12h |  | start no earlier than 2004-03-23 | Arife | 12h | 12h |
| 89 | 13.1.2 | Regular Maintenance 2 | 12h | 2004-03-30 A | 2004-03-31 A |  | 100% |  | 2004-03-30 | 2004-03-31 | 12h |  | start no earlier than 2004-03-30 | James [150%] | 12h | 12h |
| 90 | 13.1.3 | Regular Maintenance 3 | 24h | 2004-04-06 A | 2004-04-08 A |  | 100% |  | 2004-04-06 | 2004-04-08 | 24h |  | start no earlier than 2004-04-06 | Arife [75%] | 12h | 12h |
| 91 | 13.1.4 | Regular Maintenance 4 | 12h | 2004-04-13 A | 2004-04-14 A |  | 100% |  | 2004-04-13 | 2004-04-14 | 12h |  | start no earlier than 2004-04-13 | James | 12h | 12h |
| 92 | 13.1.5 | Regular Maintenance 5 | 12h | 2004-04-20 A | 2004-04-21 A |  | 100% |  | 2004-04-20 | 2004-04-21 | 12h |  | start no earlier than 2004-04-20 | Arife | 12h | 12h |
| 93 | 13.1.6 | Regular Maintenance 7 | 20h | 2004-05-10 A | 2004-05-13 A |  | 100% |  | 2004-05-10 | 2004-05-13 | 20h |  | start no earlier than 2004-05-04 | Arife | 12h | 12h |
| 94 | 13.1.7 | Regular Maintenance 8 | 20h | 2004-05-10 A | 2004-05-12 A |  | 100% |  | 2004-05-10 | 2004-05-12 | 20h |  | start no earlier than 2004-05-10 | James | 12h | 12h |
| 95 | 13.1.8 | Regular Maintenance 9 | 24h | 2004-05-18 A | 2004-05-27 A |  | 100% |  | 2004-05-18 | 2004-05-27 | 24h |  | start no earlier than 2004-05-18 | Arife [50%] | 12h | 12h |
| 96 | 13.1.9 | Regular Maintenance 10 | 12h | 2004-05-25 A | 2004-05-26 A |  | 100% |  | 2004-05-25 | 2004-05-26 | 12h |  | start no earlier than 2004-05-25 | James | 12h | 12h |
| 97 | 13.1.10 | Regular Maintenance 11 | 24h | 2004-05-28 A | 2004-06-04 A |  | 100% |  | 2004-05-28 | 2004-06-04 | 24h |  | start no earlier than 2004-05-28 | Arife [50%] | 12h | 12h |
| 98 | 13.1.11 | Regular Maintenance 12 | 12h | 2004-06-08 A | 2004-06-09 A |  | 100% |  | 2004-06-08 | 2004-06-09 | 12h |  | start no earlier than 2004-06-08 | James | 12h | 12h |
| 99 | 13.1.12 | Regular Maintenance 13 | 20h | 2004-06-14 A | 2004-06-16 A |  | 100% |  | 2004-06-14 | 2004-06-16 | 20h |  | start no earlier than 2004-06-14 | Arife | 12h | 12h |
| 100 | 13.1.13 | Regular Maintenance 14 | 12h | 2004-06-22 A | 2004-06-23 A |  | 100% |  | 2004-06-22 | 2004-06-23 | 12h |  | start no earlier than 2004-06-22 | James | 12h | 12h |
| 101 | 13.1.14 | Regular Maintenance 15 | 12h | 2004-06-29 A | 2004-06-30 A |  | 100% |  | 2004-06-29 | 2004-06-30 | 12h |  | start no earlier than 2004-06-29 | Arife | 12h | 12h |
| 102 | 13.1.15 | Regular Maintenance 16 | 12h | 2004-07-06 A | 2004-07-07 A |  | 100% |  | 2004-07-06 | 2004-07-07 | 12h |  | start no earlier than 2004-07-06 | James | 12h | 12h |
| 103 | 13.1.16 | Regular Maintenance 17 | 12h | 2004-07-13 A | 2004-07-14 A |  | 100% |  | 2004-07-13 | 2004-07-14 | 12h |  | start no earlier than 2004-07-13 | Arife | 12h | 12h |
| 104 | 13.1.17 | Regular Maintenance 18 | 12h | 2004-07-20 A | 2004-07-21 A |  | 100% |  | 2004-07-20 | 2004-07-21 | 12h |  | start no earlier than 2004-07-20 | James | 12h | 12h |
| 105 | 13.1.18 | Regular Maintenance 19 | 12h | 2004-07-27 | 2004-07-28 |  |  |  | 2004-07-27 | 2004-07-28 | 12h | 110d | start no earlier than 2004-07-27 | Arife | 12h |  |
| 106 | 13.1.19 | Regular Maintenance 20 | 12h | 2004-08-03 | 2004-08-04 |  |  |  | 2004-08-03 | 2004-08-04 | 12h | 105d | start no earlier than 2004-08-03 | James | 12h |  |
| 107 | 13.1.20 | Regular Maintenance 21 | 12h | 2004-08-10 | 2004-08-11 |  |  |  | 2004-08-10 | 2004-08-11 | 12h | 100d | start no earlier than 2004-08-10 | Arife | 12h |  |
| 108 | 13.1.21 | Regular Maintenance 22 | 12h | 2004-08-17 | 2004-08-18 |  |  |  | 2004-08-17 | 2004-08-18 | 12h | 95d | start no earlier than 2004-08-17 | James | 12h |  |
| 109 | 13.1.22 | Regular Maintenance 23 | 12h | 2004-08-24 | 2004-08-25 |  |  |  | 2004-08-24 | 2004-08-25 | 12h | 90d | start no earlier than 2004-08-24 | Arife | 12h |  |
| 110 | 13.1.23 | Regular Maintenance 24 | 12h | 2004-08-31 | 2004-09-01 |  |  |  | 2004-08-31 | 2004-09-01 | 12h | 85d | start no earlier than 2004-08-31 | James | 12h |  |
| 111 | 13.1.24 | Regular Maintenance 25 | 12h | 2004-09-07 | 2004-09-08 |  |  |  | 2004-09-07 | 2004-09-08 | 12h | 80d | start no earlier than 2004-09-07 | Arife | 12h |  |
| 112 | 13.1.25 | Regular Maintenance 26 | 12h | 2004-09-14 | 2004-09-15 |  |  |  | 2004-09-14 | 2004-09-15 | 12h | 75d | start no earlier than 2004-09-14 | James | 12h |  |
| 113 | 13.1.26 | Regular Maintenance 27 | 12h | 2004-09-21 | 2004-09-22 |  |  |  | 2004-09-21 | 2004-09-22 | 12h | 70d | start no earlier than 2004-09-21 | Arife | 12h |  |
| 114 | 13.1.27 | Regular Maintenance 28 | 12h | 2004-09-28 | 2004-09-29 |  |  |  | 2004-09-28 | 2004-09-29 | 12h | 65d | start no earlier than 2004-09-28 | James | 12h |  |
| 115 | 13.1.28 | Regular Maintenance 29 | 12h | 2004-10-05 | 2004-10-06 |  |  |  | 2004-10-05 | 2004-10-06 | 12h | 60d | start no earlier than 2004-10-05 | Arife | 12h |  |
| 116 | 13.1.29 | Regular Maintenance 30 | 12h | 2004-10-12 | 2004-10-13 |  |  |  | 2004-10-12 | 2004-10-13 | 12h | 55d | start no earlier than 2004-10-12 | James | 12h |  |
| 117 | 13.1.30 | Regular Maintenance 31 | 12h | 2004-10-19 | 2004-10-20 |  |  |  | 2004-10-19 | 2004-10-20 | 12h | 50d | start no earlier than 2004-10-19 | Arife | 12h |  |
| 118 | 13.1.31 | Regular Maintenance 32 | 12h | 2004-10-26 | 2004-10-27 |  |  |  | 2004-10-26 | 2004-10-27 | 12h | 45d | start no earlier than 2004-10-26 | James | 12h |  |
| 119 | 13.1.32 | Regular Maintenance 33 | 12h | 2004-11-02 | 2004-11-03 |  |  |  | 2004-11-02 | 2004-11-03 | 12h | 40d | start no earlier than 2004-11-02 | Arife | 12h |  |
| 120 | 13.1.33 | Regular Maintenance 34 | 12h | 2004-11-09 | 2004-11-10 |  |  |  | 2004-11-09 | 2004-11-10 | 12h | 35d | start no earlier than 2004-11-09 | James | 12h |  |
| 121 | 13.1.34 | Regular Maintenance 35 | 12h | 2004-11-16 | 2004-11-17 |  |  |  | 2004-11-16 | 2004-11-17 | 12h | 30d | start no earlier than 2004-11-16 | Arife | 12h |  |
| 122 | 13.1.35 | Regular Maintenance 36 | 12h | 2004-11-23 | 2004-11-24 |  |  |  | 2004-11-23 | 2004-11-24 | 12h | 25d | start no earlier than 2004-11-23 | James | 12h |  |
| 123 | 13.1.36 | Regular Maintenance 37 | 12h | 2004-11-30 | 2004-12-01 |  |  |  | 2004-11-30 | 2004-12-01 | 12h | 20d | start no earlier than 2004-11-30 | Arife | 12h |  |
| 124 | 13.1.37 | Regular Maintenance 38 | 12h | 2004-12-07 | 2004-12-08 |  |  |  | 2004-12-07 | 2004-12-08 | 12h | 15d | start no earlier than 2004-12-07 | James | 12h |  |
| 125 | 13.1.38 | Regular Maintenance 39 | 12h | 2004-12-14 | 2004-12-15 |  |  |  | 2004-12-14 | 2004-12-15 | 12h | 10d | start no earlier than 2004-12-14 | Arife | 12h |  |
| 126 | 13.1.39 | Regular Maintenance 40 | 12h | 2004-12-21 | 2004-12-22 |  |  |  | 2004-12-21 | 2004-12-22 | 12h | 5d | start no earlier than 2004-12-21 | James | 12h |  |
| 127 | 13.1.40 | Regular Maintenance 41 | 12h | 2004-12-28 | 2004-12-29 |  |  |  | 2004-12-28 | 2004-12-29 | 12h | 0d | start no earlier than 2004-12-28 | Arife | 12h |  |

| ID | WBS | Task | Duration | Start | Finish | Complete | Remaining | Baseline start | Baseline finish | Baseline duration | Total slack | Constraint | Resources | Work | Actual work |
| --- | --- | --- | --- | --- | --- | --- | --- | --- | --- | --- | --- | --- | --- | --- | --- |
| 128 | 13.2 | **Webstatistics** | 162d | 2004-04-06 A | 2004-12-07 | 50% | 81d | 2004-04-06 | 2004-12-07 | 162d | 15.5d |  |  | 72h | 32h |
| 129 | 13.2.1 | Webstats March | 2d | 2004-04-06 A | 2004-04-07 A | 100% |  | 2004-04-06 | 2004-04-07 | 2d |  | start no earlier than 2004-04-06 | Matthew [50%] | 8h | 8h |
| 130 | 13.2.2 | Webstats April | 1d | 2004-05-10 A | 2004-05-10 A | 100% |  | 2004-05-10 | 2004-05-10 | 1d |  | start no earlier than 2004-05-04 | Matthew | 8h | 8h |
| 131 | 13.2.3 | Webstats May | 1d | 2004-06-01 A | 2004-06-01 A | 100% |  | 2004-06-01 | 2004-06-01 | 1d |  | start no earlier than 2004-06-01 | Matthew | 8h | 8h |
| 132 | 13.2.4 | Webstats June | 1d | 2004-07-06 A | 2004-07-06 A | 100% |  | 2004-07-06 | 2004-07-06 | 1d |  | start no earlier than 2004-07-06 | Matthew | 8h | 8h |
| 133 | 13.2.5 | Webstats July | 1d | 2004-08-03 | 2004-08-03 |  |  | 2004-08-03 | 2004-08-03 | 1d | 105.5d | start no earlier than 2004-08-03 | Matthew | 8h |  |
| 134 | 13.2.6 | Webstats August | 1d | 2004-09-07 | 2004-09-07 |  |  | 2004-09-07 | 2004-09-07 | 1d | 80.5d | start no earlier than 2004-09-07 | Matthew | 8h |  |
| 135 | 13.2.7 | Webstats September | 1d | 2004-10-05 | 2004-10-05 |  |  | 2004-10-05 | 2004-10-05 | 1d | 60.5d | start no earlier than 2004-10-05 | Matthew | 8h |  |
| 136 | 13.2.8 | Webstats October | 1d | 2004-11-02 | 2004-11-02 |  |  | 2004-11-02 | 2004-11-02 | 1d | 40.5d | start no earlier than 2004-11-02 | Matthew | 8h |  |
| 137 | 13.2.9 | Webstats November | 1d | 2004-12-07 | 2004-12-07 |  |  | 2004-12-07 | 2004-12-07 | 1d | 15.5d | start no earlier than 2004-12-07 | Matthew | 8h |  |
| 138 | 13.3 | **CGI/Script maintenance** | 164d | 2004-03-30 A | 2004-12-02 | 57% | 71.3d | 2004-03-30 | 2004-12-02 | 164d | 18.5d |  |  | 144h | 64h |
| 139 | 13.3.1 | CGI/Script maintenance 1 | 4d | 2004-03-30 A | 2004-04-02 A | 100% |  | 2004-03-30 | 2004-04-02 | 4d |  | start no earlier than 2004-03-30 | Arife [75%] | 16h | 16h |
| 140 | 13.3.2 | CGI/Script maintenance 2 | 4d | 2004-05-10 A | 2004-05-27 A | 100% |  | 2004-05-10 | 2004-05-27 | 4d |  | start no earlier than 2004-05-01 | Arife [50%] | 16h | 16h |
| 141 | 13.3.3 | CGI/Script maintenance 3 | 3d | 2004-06-01 A | 2004-06-09 A | 100% |  | 2004-06-01 | 2004-06-09 | 3d |  | start no earlier than 2004-06-01 | Arife | 16h | 16h |
| 142 | 13.3.4 | CGI/Script maintenance 4 | 2d | 2004-07-01 A | 2004-07-02 A | 100% |  | 2004-07-01 | 2004-07-02 | 2d |  | start no earlier than 2004-07-01 | Arife | 16h | 16h |
| 143 | 13.3.5 | CGI/Script maintenance 5 | 2d | 2004-08-02 | 2004-08-03 |  |  | 2004-08-02 | 2004-08-03 | 2d | 105.5d | start no earlier than 2004-08-01 | Arife | 16h |  |
| 144 | 13.3.6 | CGI/Script maintenance 6 | 2d | 2004-09-01 | 2004-09-02 |  |  | 2004-09-01 | 2004-09-02 | 2d | 83.5d | start no earlier than 2004-09-01 | Arife | 16h |  |
| 145 | 13.3.7 | CGI/Script maintenance 7 | 2d | 2004-10-01 | 2004-10-04 |  |  | 2004-10-01 | 2004-10-04 | 2d | 61.5d | start no earlier than 2004-10-01 | Arife | 16h |  |
| 146 | 13.3.8 | CGI/Script maintenance 8 | 2d | 2004-11-01 | 2004-11-02 |  |  | 2004-11-01 | 2004-11-02 | 2d | 40.5d | start no earlier than 2004-11-01 | Arife | 16h |  |
| 147 | 13.3.9 | CGI/Script maintenance 9 | 2d | 2004-12-01 | 2004-12-02 |  |  | 2004-12-01 | 2004-12-02 | 2d | 18.5d | start no earlier than 2004-12-01 | Arife | 16h |  |
| 149 | 14 | **Other duties** | 58.61d | 2004-03-22 A | 2004-06-30 A | 100% |  | 2004-03-22 | 2004-06-30 | 58.61d |  |  |  | 144h | 144h |
| 150 | 14.1 | TTM shifts | 4d | 2004-03-22 A | 2004-03-26 A | 100% |  | 2004-03-22 | 2004-03-26 | 4d |  |  | James | 32h | 32h |
| 151 | 14.2 | Assorted TTM work | 3.8w | 2004-04-19 A | 2004-06-30 A | 100% |  | 2004-04-19 | 2004-06-30 | 3.8w |  | start no earlier than 2004-04-19 | James | 112h | 112h |
